# Malware Protection Overhaul Aug28

Schedule from MS Project, 2012-11-05 to 2013-09-01, A marks actual dates.
MIT

## Calendars

- Standard: Mon-Fri 08:00-12:00, 13:00-17:00; Sat-Sun off. Exceptions (off unless hours are given): 2013-06-01 08:00-12:00, 13:00-17:00, 2013-09-01 08:00-12:00, 13:00-17:00.

## Resources

| Resource |
| --- |
| Andrew |
| Sophie |
| Richard |
| Tim |
| Monique |
| justin |
| Monique/dave C |
| N/A |

## Schedule

| ID | WBS | Task | Type | Duration | Start | Finish | Complete | Resources | Work | Actual work |
| --- | --- | --- | --- | --- | --- | --- | --- | --- | --- | --- |
| 1 | 1 | **Malware Protection Overhaul Project** |  | 217d? | 2012-11-05 A | 2013-09-01 A | 100% |  | 4248h | 4248h |
| 2 | 1.1 | **Planning** |  | 1d | 2012-11-05 A | 2012-11-05 A | 100% |  | 24h | 24h |
| 3 | 1.1.1 | Define scope | manual | 1d | 2012-11-05 A | 2012-11-05 A | 100% | Sophie | 8h | 8h |
| 4 | 1.1.2 | Review scope with Mark | manual | 1d | 2012-11-05 A | 2012-11-05 A | 100% | Sophie | 8h | 8h |
| 5 | 1.1.3 | Kickoff Meeting - include other teams | manual | 1d | 2012-11-05 A | 2012-11-05 A | 100% | Sophie | 8h | 8h |
| 6 | 1.2 | **Project Communications** |  | 1d? | 2012-11-14 A | 2012-11-14 A | 100% |  | 24h | 24h |
| 7 | 1.2.1 | Initial IT Leader meeting presentation |  | 1d? | 2012-11-14 A | 2012-11-14 A | 100% | Andrew | 8h | 8h |
| 8 | 1.2.2 | Contact IT Leaders to solicite volunteers for evaluations | manual | 1d | 2012-11-14 A | 2012-11-14 A | 100% | Tim | 8h | 8h |
| 9 | 1.2.3 | Checklist for pilot | manual | 1d | 2012-11-14 A | 2012-11-14 A | 100% | Andrew | 8h | 8h |
| 10 | 1.3 | **Vendor Selection** |  | 130d | 2012-11-14 A | 2013-05-14 A | 100% |  | 24h | 24h |
| 11 | 1.3.1 | **Sophos Evaluation** |  | 47d | 2012-11-28 A | 2013-01-31 A | 100% |  |  |  |
| 12 | 1.3.1.1 | VM setup | manual | 1d | 2012-11-28 A | 2012-11-28 A | 100% |  |  |  |
| 13 | 1.3.1.2 | Console setup | manual | 1d | 2012-12-05 A | 2012-12-05 A | 100% |  |  |  |
| 14 | 1.3.1.3 | Console and client functionality evaluation | manual | 1d | 2012-11-28 A | 2012-11-28 A | 100% |  |  |  |
| 15 | 1.3.1.4 | Document Pros and cons | manual | 1d | 2013-01-31 A | 2013-01-31 A | 100% |  |  |  |
| 16 | 1.3.2 | **ESET Evaluation (v5.0 - Jan 2013)** |  | 42d | 2012-12-05 A | 2013-01-31 A | 100% |  |  |  |
| 17 | 1.3.2.1 | VM setup | manual | 1d | 2012-12-05 A | 2012-12-05 A | 100% |  |  |  |
| 18 | 1.3.2.2 | Console setup | manual | 1d | 2012-12-05 A | 2012-12-05 A | 100% |  |  |  |
| 19 | 1.3.2.3 | Console and client functionality evaluation | manual | 1d | 2012-12-05 A | 2012-12-05 A | 100% |  |  |  |
| 20 | 1.3.2.4 | Document pros and cons | manual | 1d | 2013-01-31 A | 2013-01-31 A | 100% |  |  |  |
| 21 | 1.3.3 | **System Center 2012 (Forefront) Evaluation** |  | 57d | 2012-11-14 A | 2013-01-31 A | 100% |  | 16h | 16h |
| 22 | 1.3.3.1 | VM setup | manual | 1d | 2012-11-14 A | 2012-11-14 A | 100% | Richard | 8h | 8h |
| 23 | 1.3.3.2 | Console setup | manual | 1d | 2012-11-14 A | 2012-11-14 A | 100% | Richard | 8h | 8h |
| 24 | 1.3.3.3 | Console and client functionality evaluation | manual | 1d | 2013-01-31 A | 2013-01-31 A | 100% |  |  |  |

| ID | WBS | Task | Type | Duration | Start | Finish | Predecessors | Complete | Actual start | Actual finish | Constraint | Resources | Work | Actual work |
| --- | --- | --- | --- | --- | --- | --- | --- | --- | --- | --- | --- | --- | --- | --- |
| 25 | 1.3.4 | **ESET Evaluation (v5.0 - Jan 2013)** |  | 1d | 2012-11-14 A | 2012-11-14 A |  | 100% |  |  |  |  |  |  |
| 26 | 1.3.4.1 | VM setup | manual | 1d | 2012-11-14 A | 2012-11-14 A |  | 100% |  |  |  |  |  |  |
| 27 | 1.3.4.2 | Console setup | manual | 1d | 2012-11-14 A | 2012-11-14 A |  | 100% |  |  |  |  |  |  |
| 28 | 1.3.4.3 | Console and client functionality evaluation | manual | 1d | 2012-11-14 A | 2012-11-14 A |  | 100% |  |  |  |  |  |  |
| 29 | 1.3.5 | **Vendor Demo** |  | 67d | 2012-11-14 A | 2013-02-14 A |  | 100% |  |  |  |  |  |  |
| 30 | 1.3.5.1 | Determine invitees | manual | 1d | 2012-11-14 A | 2012-11-14 A |  | 100% |  |  |  |  |  |  |
| 31 | 1.3.5.2 | Determine requirements | manual | 1d | 2013-02-01 A | 2013-02-01 A |  | 100% |  |  |  |  |  |  |
| 32 | 1.3.5.3 | Demo | manual | 10d | 2013-02-01 A | 2013-02-14 A |  | 100% |  |  |  |  |  |  |
| 33 | 1.3.5.4 | Team feedback | manual | 2d | 2013-02-01 A | 2013-02-04 A |  | 100% |  |  |  |  |  |  |
| 34 | 1.3.6 | **Analyze Recommendation and Solution** |  | 70d | 2012-11-14 A | 2013-02-19 A |  | 100% |  |  |  |  | 8h | 8h |
| 35 | 1.3.6.1 | Peer school comparion breakdown | manual | 1d | 2012-11-14 A | 2012-11-14 A |  | 100% |  |  |  | Andrew | 8h | 8h |
| 36 | 1.3.6.2 | Determine any contract/licensing issues | manual | 1d | 2013-02-15 A | 2013-02-15 A | 32 | 100% |  |  |  |  |  |  |
| 37 | 1.3.6.3 | Determine total cost of ownership |  | 1d | 2013-02-15 A | 2013-02-15 A | 32 | 100% |  |  |  |  |  |  |
| 38 | 1.3.6.4 | Determine benefits and concerns |  | 1d | 2013-02-18 A | 2013-02-18 A | 37 | 100% |  |  |  |  |  |  |
| 39 | 1.3.6.5 | Determine support process/structure |  | 1d | 2013-02-19 A | 2013-02-19 A | 38 | 100% |  |  |  |  |  |  |
| 40 | 1.3.7 | **Sponsor approval** |  | 5d | 2013-02-19 | 2013-02-26 | 34 | 100% | 2013-05-08 | 2013-05-14 |  |  |  |  |
| 41 | 1.3.7.1 | Approval from sponsor | manual | 5d | 2013-05-08 A | 2013-05-14 A |  | 100% |  |  |  |  |  |  |
| 42 | 1.4 | **McAfee License** |  | 37d | 2013-04-08 A | 2013-05-28 A |  | 100% |  |  |  | Sophie | 296h | 296h |
| 43 | 1.4.1 | Understand current McAfee license constraints |  | 1d | 2013-04-08 A | 2013-04-08 A |  | 100% |  |  |  |  |  |  |
| 44 | 1.4.2 | Understand what the license needs are | manual | 10d | 2013-05-08 A | 2013-05-21 A |  | 100% |  |  |  |  |  |  |
| 45 | 1.4.3 | Adjust McAfee license based on new requirements |  | 5d | 2013-05-22 A | 2013-05-28 A | 44 | 100% |  |  |  |  |  |  |
| 46 | 1.5 | **Planning with IS&T Teams** |  | 30d | 2013-05-16 A | 2013-06-25 A | 41 | 100% |  |  |  | Sophie | 256h | 256h |
| 47 | 1.5.1 | Helpdesk Planning & Support |  | 5d | 2013-05-22 A | 2013-05-28 A |  | 100% |  |  | start no earlier than 2013-05-22 |  |  |  |
| 48 | 1.5.2 | DITR Planning & Support |  | 5d | 2013-05-22 A | 2013-05-28 A |  | 100% |  |  | start no earlier than 2013-05-22 |  |  |  |
| 49 | 1.5.3 | SWRT Planning & Support |  | 1d | 2013-05-16 A | 2013-05-16 A |  | 100% |  |  |  |  |  |  |
| 50 | 1.5.4 | Followup meeting with IS&T teams/checkpoint |  | 1d | 2013-06-19 A | 2013-06-19 A | 77FS-5d | 100% |  |  | start no earlier than 2013-06-10 | Andrew | 8h | 8h |
| 51 | 1.5.5 | Followup meeting with SWRT |  | 1d | 2013-06-25 A | 2013-06-25 A |  | 100% |  |  | start no earlier than 2013-06-25 | Andrew | 8h | 8h |

| ID | WBS | Task | Type | Duration | Start | Finish | Predecessors | Complete | Actual start | Actual finish | Constraint | Resources | Work | Actual work |
| --- | --- | --- | --- | --- | --- | --- | --- | --- | --- | --- | --- | --- | --- | --- |
| 52 | 1.6 | **Documentations** |  | 21d? | 2013-05-22 A | 2013-06-18 A |  | 100% |  |  |  | Monique | 1496h | 1496h |
| 53 | 1.6.1 | Doc needs identified by IS&T Teams |  | 1d? | 2013-05-22 A | 2013-05-22 A |  | 100% |  |  | start no earlier than 2013-05-22 |  |  |  |
| 54 | 1.6.2 | **KB Documentation** |  | 21d | 2013-05-22 A | 2013-06-18 A |  | 100% |  |  |  |  | 1168h | 1168h |
| 55 | 1.6.2.1 | Install Doc |  | 20d | 2013-05-22 A | 2013-06-17 A |  | 100% |  |  | start no earlier than 2013-05-22 | Monique | 160h | 160h |
| 56 | 1.6.2.2 | Uninstall Doc |  | 20d | 2013-05-22 A | 2013-06-17 A |  | 100% |  |  | start no earlier than 2013-05-22 | Monique | 160h | 160h |
| 57 | 1.6.2.3 | Why one must uninstall before installing |  | 20d | 2013-05-22 A | 2013-06-17 A |  | 100% |  |  | start no earlier than 2013-05-22 | Monique | 160h | 160h |
| 58 | 1.6.2.4 | Escalation procedures |  | 20d | 2013-05-22 A | 2013-06-17 A |  | 100% |  |  | start no earlier than 2013-05-22 | Monique | 160h | 160h |
| 59 | 1.6.2.5 | Recommendations for students who wants to use other AV products and not connect to console |  | 20d | 2013-05-22 A | 2013-06-17 A |  | 100% |  |  | start no earlier than 2013-05-22 | Monique | 160h | 160h |
| 60 | 1.6.2.6 | Language on console managment | manual | 20d | 2013-05-22 A | 2013-06-17 A |  | 100% |  |  |  | Monique | 160h | 160h |
| 61 | 1.6.2.7 | How often does it scan question | manual | 20d | 2013-05-22 A | 2013-06-17 A |  | 100% |  |  |  | Monique | 160h | 160h |
| 62 | 1.6.2.8 | Landing page asking users to agree to remove when no longer affiliated with MIT |  | 6d | 2013-06-11 A | 2013-06-18 A |  | 100% |  |  | start no earlier than 2013-06-11 | Monique/dave C | 48h | 48h |
| 63 | 1.6.3 | 3 Prod landing pages (mac, PC, Linux) |  | 20d | 2013-05-22 A | 2013-06-17 A |  | 100% |  |  | start no earlier than 2013-05-22 | justin | 160h | 160h |
| 64 | 1.7 | **Communications** |  | 210d? | 2012-11-14 A | 2013-09-01 A |  | 100% |  |  |  | Monique | 1712h | 1712h |
| 65 | 1.7.1 | IT Partners initial communications |  | 1d? | 2012-11-14 A | 2012-11-14 A |  | 100% |  |  |  |  |  |  |
| 66 | 1.7.2 | To ITLeaders, ITPartners, IS&T on recommendation |  | 1d? | 2013-05-14 A | 2013-05-14 A |  | 100% |  |  | start no earlier than 2013-05-14 |  |  |  |
| 67 | 1.7.3 | To ITLeaders, ITPartners, IS&T - upcoming testing |  | 1d? | 2013-05-14 A | 2013-05-14 A |  | 100% |  |  |  |  |  |  |
| 68 | 1.7.4 | Notification and instructions for full integ testing |  | 1d? | 2013-06-04 A | 2013-06-04 A |  | 100% |  |  | start no earlier than 2013-06-04 | Andrew | 8h | 8h |
| 69 | 1.7.5 | What does this mean to you DLCs? |  | 1d? | 2013-06-27 A | 2013-06-27 A | 77FS+1d | 100% |  |  | start no earlier than 2013-06-03 | Monique | 8h | 8h |
| 70 | 1.7.6 | We want your feedback - post testing | manual | 1d | 2013-06-25 A | 2013-06-25 A | 77 | 100% |  |  |  | Monique | 8h | 8h |
| 71 | 1.7.7 | August - back to school reminder communications |  | 1d? | 2013-09-01 A | 2013-09-01 A |  | 100% |  |  | start no earlier than 2013-09-01 | Monique | 8h | 8h |
| 72 | 1.8 | **Full Integration Testing** |  | 10d | 2013-02-26 | 2013-03-12 |  | 100% | 2013-05-09 | 2013-06-28 |  |  | 80h | 80h |
| 73 | 1.8.1 | Setup |  | 7d | 2013-06-03 A | 2013-06-11 A |  | 100% |  |  | finish no earlier than 2013-06-11 | Andrew | 56h | 56h |
| 74 | 1.8.2 | Determine testing team |  | 5d | 2013-05-12 A | 2013-05-17 A |  | 100% |  |  | start no earlier than 2013-05-09 |  |  |  |
| 75 | 1.8.3 | Determine timelines |  | 1d? | 2013-05-09 A | 2013-05-09 A | 41 | 100% |  |  |  |  |  |  |
| 76 | 1.8.4 | Determine testing support process |  | 1d | 2013-05-22 A | 2013-05-22 A |  | 100% |  |  | start no earlier than 2013-05-22 |  |  |  |
| 77 | 1.8.5 | Full Integration testing |  | 10d | 2013-06-12 A | 2013-06-25 A | 73, 74, 76 | 100% |  |  |  |  |  |  |
| 78 | 1.8.6 | Collect feedback |  | 2d | 2013-06-26 A | 2013-06-27 A | 77 | 100% |  |  |  | Andrew | 16h | 16h |
| 79 | 1.8.7 | Checkpoint: Present pilot rollout feedback to Sponsor |  | 1d | 2013-06-28 A | 2013-06-28 A | 78 | 100% |  |  |  | Andrew | 8h | 8h |

| ID | WBS | Task | Duration | Start | Finish | Predecessors | Complete | Constraint | Resources | Work | Actual work |
| --- | --- | --- | --- | --- | --- | --- | --- | --- | --- | --- | --- |
| 80 | 1.9 | **Procurement** | 34d? | 2013-05-15 A | 2013-06-28 A |  | 100% |  |  | 16h | 16h |
| 81 | 1.9.1 | Negotiate pricing | 2d | 2013-05-15 A | 2013-05-16 A | 41 | 100% |  | Sophie | 16h | 16h |
| 82 | 1.9.2 | Contract agreement and signature | 5d | 2013-05-17 A | 2013-05-23 A | 81 | 100% |  |  |  |  |
| 83 | 1.9.3 | Purchase | 2d | 2013-06-27 A | 2013-06-28 A | 82, 79 | 100% |  |  |  |  |
| 84 | 1.9.4 | Reminder: adjust McAfee contract | 1d? | 2013-06-28 A | 2013-06-28 A |  | 100% | start no earlier than 2013-06-28 |  |  |  |
| 85 | 1.10 | **Software release Grid** | 1d | 2013-07-01 A | 2013-07-01 A |  | 100% |  |  |  |  |
| 86 | 1.10.1 | Available | 1d | 2013-07-01 A | 2013-07-01 A | 79, 83 | 100% | start no earlier than 2012-11-14 |  |  |  |
| 87 | 1.11 | **Domain User Rollout (phased)** | 19d? | 2013-07-02 A | 2013-07-26 A | 86 | 100% |  | Richard | 304h | 304h |
| 88 | 1.11.1 | IS&T phased | 1d? | 2013-07-02 A | 2013-07-02 A | 79, 83 | 100% |  | Richard | 8h | 8h |
| 89 | 1.11.2 | wait period | 5d | 2013-07-03 A | 2013-07-09 A | 88 | 100% |  | Richard | 40h | 40h |
| 90 | 1.11.3 | IS&T all | 1d? | 2013-07-10 A | 2013-07-10 A | 89 | 100% |  | Richard | 8h | 8h |
| 91 | 1.11.4 | wait period | 5d | 2013-07-11 A | 2013-07-17 A | 90 | 100% |  | Richard | 40h | 40h |
| 92 | 1.11.5 | group 1 | 1d? | 2013-07-18 A | 2013-07-18 A | 91 | 100% |  | Richard | 8h | 8h |
| 93 | 1.11.6 | wait period | 5d | 2013-07-19 A | 2013-07-25 A | 92 | 100% |  | Richard | 40h | 40h |
| 94 | 1.11.7 | group 2 | 1d? | 2013-07-26 A | 2013-07-26 A | 93 | 100% |  | Richard | 8h | 8h |
| 95 | 1.12 | **Project Wrapup** | 1d? | 2013-07-29 A | 2013-07-29 A | 88 | 100% |  | Richard | 16h | 16h |
| 96 | 1.12.1 | closeout project | 1d? | 2013-07-29 A | 2013-07-29 A | 87 | 100% |  | Richard | 8h | 8h |
